# Proyect4

Schedule from MS Project, 2009-06-22 to 2009-07-18, A marks actual dates.

## Calendars

- Estándar: Mon-Sat 09:00-13:00, 15:00-19:00; Sun off.

## Schedule

| ID | WBS | Task | Duration | Start | Finish | Predecessors | Complete | Baseline start | Baseline finish | Baseline duration | Constraint |
| --- | --- | --- | --- | --- | --- | --- | --- | --- | --- | --- | --- |
| 1 | 1 | **PROGRAMA PARA LA REPARACION DE LA INDICACION DEL KM 18+134.57 DEL OLEODUCTO DE 16"Ø BELLOTA - EDEN - CARDENAS NORTE.** | 24d? | 2009-06-22 A | 2009-07-18 A |  | 100% | 2009-06-22 | 2009-07-18 | 24d? |  |
| 2 | 1.1 | UBICACIÓN GEOGRAFICA DE LA INDICACION MEDIANTE COORDENADAS GPS. | 1d? | 2009-06-22 A | 2009-06-22 A |  | 100% | 2009-06-22 | 2009-06-22 | 1d? | start no earlier than 2009-06-22 |
| 3 | 1.2 | TRAMITES DE PERMISOS DE PASO. | 4d? | 2009-06-23 A | 2009-06-26 A | 2 | 100% | 2009-06-23 | 2009-06-26 | 4d? | finish no earlier than 2009-06-26 |
| 4 | 1.3 | ACONDICIONAMIENTO DEL AREA DE TRABAJO Y ACCESO AL SITIO DE TRABAJO. | 3d? | 2009-06-27 A | 2009-06-30 A | 3 | 100% | 2009-06-27 | 2009-06-30 | 3d? | finish no earlier than 2009-06-30 |
| 5 | 1.4 | CORRELACION DE CARRETES POR MEDIO DE SOLDADURAS DE REFERENCIA. | 1d? | 2009-06-30 A | 2009-06-30 A | 4FF | 100% | 2009-06-30 | 2009-06-30 | 1d? | start no earlier than 2009-06-30 |
| 6 | 1.5 | FABRICACION E INSTALACION DE CERCOS DE PROTECCION CON LETREROS DE SEGURIDAD. | 1d? | 2009-07-01 A | 2009-07-01 A | 5 | 100% | 2009-07-01 | 2009-07-01 | 1d? | start no earlier than 2009-07-01 |
| 7 | 1.6 | EXCAVACION, DEZASOLVE Y BOMBEO DE ACHIQUE EN TERRENO: FIRME, PANTANOSO, INUNDABLE O LACUSTRE ( RIO, LAGUNA O CANAL ). | 2d? | 2009-07-01 A | 2009-07-02 A | 6SS | 100% | 2009-07-01 | 2009-07-02 | 2d? | finish no earlier than 2009-07-02 |
| 8 | 1.7 | LIMPIEZA EXTERIOR DEL DUCTO CON RETIRO DE LASTRE Y RECUBRIMIENTO DIELECTRICO. | 2d? | 2009-07-03 A | 2009-07-04 A | 7 | 100% | 2009-07-03 | 2009-07-04 | 2d? | finish no earlier than 2009-07-04 |
| 9 | 1.8 | VERIFICACION DE LA INDICACION MEDIANTE INSPECCION VISUAL Y ULTRASONICA, DEFINIENDOSE LA ZONA SANA. | 2d? | 2009-07-06 A | 2009-07-07 A | 8 | 100% | 2009-07-06 | 2009-07-07 | 2d? | finish no earlier than 2009-07-07 |
| 10 | 1.9 | EVALUACION Y ANALISIS DE INTEGRIDAD DE INDICACIONES APLICANDO CODIGOS Y NORMAS. | 3d? | 2009-07-08 A | 2009-07-10 A | 9 | 100% | 2009-07-08 | 2009-07-10 | 3d? | finish no earlier than 2009-07-10 |
| 11 | 1.10 | REPARACION MEDIANTE ENVOLVENTE METALICA DE LA LONGITUD DEL SEGMENTO DEL DUCTO ( SI SE REQUIERE ). | 4d? | 2009-07-11 A | 2009-07-15 A | 10 | 100% | 2009-07-11 | 2009-07-15 | 4d? | finish no earlier than 2009-07-15 |
| 12 | 1.11 | REPOSICION DEL RECUBRIMIENTO DIELECTRICO DEL TRAMO REPARADO. | 1d? | 2009-07-16 A | 2009-07-16 A |  | 100% | 2009-07-16 | 2009-07-16 | 1d? | start no earlier than 2009-07-16 |
| 13 | 1.12 | TAPADO Y COMPACTADO DE RELLENO EN EXCAVACION. | 1d? | 2009-07-17 A | 2009-07-17 A |  | 100% | 2009-07-17 | 2009-07-17 | 1d? | start no earlier than 2009-07-17 |
| 14 | 1.13 | RESTAURACION DEL TERRENO. | 1d? | 2009-07-18 A | 2009-07-18 A |  | 100% | 2009-07-18 | 2009-07-18 | 1d? | start no earlier than 2009-07-18 |
